# UCATS Schedule_2009-10-13

How a schedule from MS Project changed from version to version. A marks actual dates.

## Version 1 (saved 2009-10-13, file UCATS Schedule_2009-10-13.mpp)

| ID | WBS | Task | Duration | Start | Finish | Predecessors | Total float | Constraint |
| --- | --- | --- | --- | --- | --- | --- | --- | --- |
| 1 | 1 | **Project Management** | 109d? | 2009-08-31 | 2009-12-18 |  | 0d |  |
| 2 |  | Organize Team | 0d | 2009-08-31 | 2009-08-31 |  | 0d | finish no earlier than 2009-08-31 |
| 3 |  | Select Concept | 4d | 2009-09-01 | 2009-09-04 | 2 | 0d |  |
| 4 | 1.3 | **Generate Project Proposal** | 10d | 2009-09-05 | 2009-09-14 | 3 | 0d |  |
| 5 |  | Project Proposal Presentation | 9d | 2009-09-05 | 2009-09-13 |  | 0d |  |
| 6 |  | Project Proposal Summary | 9d | 2009-09-05 | 2009-09-13 |  | 0d |  |
| 7 |  | Proposal Scoped and Approved | 0d | 2009-09-14 | 2009-09-14 | 5FS+1d, 6FS+1d | 0d |  |
| 8 |  | Project Management Plan | 8d | 2009-09-05 | 2009-09-12 | 3 | 89d |  |
| 9 |  | Networked Schedule | 8d | 2009-09-13 | 2009-09-20 | 8 | 89d |  |
| 10 |  | System Business Concept | 9d? | 2009-09-15 | 2009-09-23 | 7 | 0d |  |
| 11 |  | Stakeholder Value Mapping | 8d? | 2009-09-15 | 2009-09-22 |  | 87d | start no earlier than 2009-09-15 |
| 12 |  | SOW | 8d? | 2009-09-15 | 2009-09-22 |  | 87d | start no earlier than 2009-09-15 |
| 13 | 1.9 | **Reporting** | 84d | 2009-09-25 | 2009-12-18 |  | 0d |  |
| 14 | 1.9.1 | **Final Presentation** | 63d | 2009-10-17 | 2009-12-18 |  | 0d |  |
| 15 |  | Rough Draft Presentation | 28d | 2009-10-17 | 2009-11-13 | 74 | 0d |  |
| 16 |  | Final Draft Presentation | 35d | 2009-11-14 | 2009-12-18 | 15 | 0d |  |
| 17 | 1.9.2 | **Final Report** | 63d | 2009-10-17 | 2009-12-18 |  | 0d |  |
| 18 |  | Rough Draft Report | 28d | 2009-10-17 | 2009-11-13 | 74 | 0d |  |
| 19 |  | Final Draft Report | 35d | 2009-11-14 | 2009-12-18 | 18 | 0d |  |
| 20 | 1.9.3 | **Reviews** | 83d | 2009-09-25 | 2009-12-18 |  | 1d |  |
| 21 |  | SRR | 0d | 2009-09-25 | 2009-09-25 | 45 | 84d |  |
| 22 |  | CDR | 0d | 2009-12-18 | 2009-12-18 |  | 1d | start no earlier than 2009-12-18 |
| 23 | 2 | **Systems Engineering Management** | 21d? | 2009-09-15 | 2009-10-05 | 7 | 74d |  |
| 24 |  | Systems Engineering Tools Selection | 1d? | 2009-09-15 | 2009-09-15 |  | 94d |  |
| 25 |  | CM | 1d? | 2009-09-15 | 2009-09-15 |  | 94d |  |
| 26 |  | Systems Engineering Management Plan (SEMP) | 21d? | 2009-09-15 | 2009-10-05 |  | 74d | finish no earlier than 2009-10-05 |
| 27 |  | Risk Management Plan (RMP) | 21d? | 2009-09-15 | 2009-10-05 |  | 74d | finish no earlier than 2009-10-05 |
| 28 |  | Product Assurance Plan (PAP) | 21d? | 2009-09-15 | 2009-10-05 |  | 74d | finish no earlier than 2009-10-05 |
| 29 | 3 | **System Design** | 32d? | 2009-09-15 | 2009-10-16 |  | 5d |  |
| 30 | 3.1 | **Define System Level Design Problem** | 12d? | 2009-09-15 | 2009-09-26 | 7 | 5d |  |
| 31 |  | Develop Concept of Operation | 2d | 2009-09-15 | 2009-09-16 |  | 5d |  |
| 32 | 3.1.2 | **Develop External Systems Diagram** | 2d | 2009-09-15 | 2009-09-16 |  | 93d |  |
| 33 |  | Identify External Interface Requirements | 2d | 2009-09-15 | 2009-09-16 |  | 93d |  |
| 34 |  | Develop External Systems Activity Diagram | 9d? | 2009-09-15 | 2009-09-23 |  | 86d | finish no earlier than 2009-09-23 |
| 35 |  | Develop External Systems Diagram | 2d? | 2009-09-15 | 2009-09-16 |  | 5d | finish no earlier than 2009-09-16 |
| 36 |  | Develop Systems Objectives Hierarchy | 2d | 2009-09-15 | 2009-09-16 |  | 93d |  |
| 37 | 3.1.6 | **Develop Analyze and Refine Requirements** | 9d | 2009-09-17 | 2009-09-25 | 35 | 5d |  |
| 38 |  | Develop Use Cases for CONOPs | 1d | 2009-09-17 | 2009-09-17 | 31 | 5d |  |
| 39 |  | Develop Sequence Diagrams for Use Cases | 1d | 2009-09-18 | 2009-09-18 | 38 | 5d |  |
| 40 |  | Develop Communications Diagram | 1d | 2009-09-18 | 2009-09-18 | 38 | 5d |  |
| 41 |  | Systems Objectives Hierarchy | 1d | 2009-09-18 | 2009-09-18 | 38 | 5d |  |
| 42 |  | Define Draft Requirements | 1d | 2009-09-24 | 2009-09-24 | 38, 39, 40, 41, 10 | 0d |  |
| 43 |  | Define Qualification Requirements | 1d | 2009-09-18 | 2009-09-18 | 38 | 91d |  |
| 44 |  | Ensure Requirements Feasibility | 1d | 2009-09-25 | 2009-09-25 | 42 | 0d |  |
| 45 |  | Obtain Approval for Requirements | 0d | 2009-09-25 | 2009-09-25 | 44 | 0d |  |
| 46 |  | Document Final Requirements | 1d | 2009-09-26 | 2009-09-26 | 45 | 0d |  |
| 47 | 3.2 | **Develop System Functional Architecture** | 7d | 2009-09-27 | 2009-10-03 | 7 | 0d |  |
| 48 |  | Create Simple Functional Concept | 1d | 2009-09-27 | 2009-09-27 | 46 | 0d |  |
| 49 | 3.2.2 | **Draft and Evaluate Functional Model** | 3d | 2009-09-28 | 2009-09-30 |  | 0d |  |
| 50 |  | Conduct Functional Decomposition Brainstorming | 1d | 2009-09-28 | 2009-09-28 | 48 | 0d |  |
| 51 |  | Conduct Functional Decomposition Trade-Study | 1d | 2009-09-29 | 2009-09-29 | 50 | 0d |  |
| 52 |  | Select Functional Decomposition | 1d | 2009-09-30 | 2009-09-30 | 51 | 0d |  |
| 53 | 3.2.3 | **Complete Functional and Data Models** | 1d | 2009-10-01 | 2009-10-01 |  | 0d |  |
| 54 |  | Generate Initial Functional Model | 1d | 2009-10-01 | 2009-10-01 | 52 | 0d |  |
| 55 |  | Generate Activity Diagrams | 1d | 2009-10-01 | 2009-10-01 | 52 | 0d |  |
| 56 |  | Identify Draft Sub-System Interface Requirements | 1d | 2009-10-01 | 2009-10-01 | 52 | 0d |  |
| 57 | 3.2.4 | **Trace Input / Output Requirements** | 1d | 2009-10-02 | 2009-10-02 | 53 | 0d |  |
| 58 |  | Complete Draft IDEF A0 Diagram | 1d | 2009-10-02 | 2009-10-02 |  | 0d |  |
| 59 |  | Obtain Approval for Functional Architecture | 0d | 2009-10-02 | 2009-10-02 | 58 | 0d |  |
| 60 |  | Document Final Functional Architecture | 1d | 2009-10-03 | 2009-10-03 | 59 | 0d |  |
| 61 | 3.3 | **Develop System Instantiatedl Architecture** | 13d? | 2009-10-04 | 2009-10-16 | 7 | 0d |  |
| 62 | 3.3.1 | **Develop Generic Architecture** | 3d | 2009-10-04 | 2009-10-06 |  | 0d |  |
| 63 |  | Brainstorm Architecture | 1d | 2009-10-04 | 2009-10-04 | 60 | 0d |  |
| 64 |  | Generate Trade-Off Analysis | 1d | 2009-10-05 | 2009-10-05 | 63 | 0d |  |
| 65 |  | Down-Select Generic Architecture | 1d | 2009-10-06 | 2009-10-06 | 64 | 0d |  |
| 66 | 3.3.2 | **Develop Instantiated Architecture** | 9d | 2009-10-07 | 2009-10-15 |  | 0d |  |
| 67 |  | Brainstorm Instantiated Architecture Components | 1d | 2009-10-07 | 2009-10-07 | 65 | 0d |  |
| 68 |  | Generate Morphological Box - Instantiated Arch Sub-Sys | 2d | 2009-10-08 | 2009-10-09 | 67 | 0d |  |
| 69 |  | Conduct Sub-System Trade-Off Analysis | 3d | 2009-10-10 | 2009-10-12 | 68 | 0d |  |
| 70 |  | Down Select Instantiated Architecture | 1d | 2009-10-13 | 2009-10-13 | 69 | 0d |  |

| ID | WBS | Task | Duration | Start | Finish | Predecessors | Total float |
| --- | --- | --- | --- | --- | --- | --- | --- |
| 71 |  | Finalize Sub-System Interface Requirements | 1d | 2009-10-14 | 2009-10-14 | 70 | 0d |
| 72 |  | Document Instantiated Draft Design | 1d | 2009-10-15 | 2009-10-15 | 71 | 0d |
| 73 |  | Obtain Approval for Instantiated Design | 0d | 2009-10-15 | 2009-10-15 | 72 | 0d |
| 74 |  | Final Instantiated Design | 1d? | 2009-10-16 | 2009-10-16 | 73 | 0d |
| 75 | 4 | **Refine / Update Design** | 60d | 2009-10-17 | 2009-12-15 | 74 | 3d |
| 76 |  | System Requirements | 60d | 2009-10-17 | 2009-12-15 |  | 3d |
| 77 |  | Functional Design | 60d | 2009-10-17 | 2009-12-15 |  | 3d |
| 78 |  | Instantiated Design | 60d | 2009-10-17 | 2009-12-15 |  | 3d |

## Version 2 (saved 2009-10-13, file UCATS Schedule_2009-10-13_Tracking.mpp)

Last finish stays 2009-12-18. Complete tasks 0 → 34.

Removed: 39 Develop Sequence Diagrams for Use Cases; 40 Develop Communications Diagram; 41 Systems Objectives Hierarchy

Changed:

| ID | Task | Start | Finish | Duration | Complete | Total float | Predecessors |
| --- | --- | --- | --- | --- | --- | --- | --- |
| 1 | **Project Management** | 2009-08-31 A |  |  | 0% → 98% |  |  |
| 2 | Organize Team | 2009-08-31 A | 2009-08-31 A | 0d → 1d | 0% → 100% | 0d → none |  |
| 3 | Select Concept | 2009-09-01 → 2009-08-31 A (-1d) | 2009-09-04 → 2009-09-03 A (-1d) |  | 0% → 100% | 0d → none |  |
| 4 | **Generate Project Proposal** | 2009-09-05 → 2009-09-04 A (-1d) | 2009-09-14 → 2009-09-13 A (-1d) |  | 0% → 100% | 0d → none |  |
| 5 | Project Proposal Presentation | 2009-09-05 → 2009-09-04 A (-1d) | 2009-09-13 → 2009-09-12 A (-1d) |  | 0% → 100% | 0d → none |  |
| 6 | Project Proposal Summary | 2009-09-05 → 2009-09-04 A (-1d) | 2009-09-13 → 2009-09-12 A (-1d) |  | 0% → 100% | 0d → none |  |
| 7 | Proposal Scoped and Approved | 2009-09-14 → 2009-09-13 A (-1d) | 2009-09-14 → 2009-09-13 A (-1d) |  | 0% → 100% | 0d → none |  |
| 8 | Project Management Plan | 2009-09-05 → 2009-09-08 A (+3d) | 2009-09-12 → 2009-09-14 A (+2d) | 8d → 7d | 0% → 100% | 89d → none |  |
| 9 | Networked Schedule | 2009-09-13 → 2009-09-08 A (-5d) | 2009-09-20 → 2009-09-14 A (-6d) | 8d → 7d | 0% → 100% | 89d → none |  |
| 10 | System Business Concept | 2009-09-15 → 2009-09-14 A (-1d) | 2009-09-23 → 2009-09-22 (-1d) |  | 0% → 50% | 0d → 86d |  |
| 11 | Stakeholder Value Mapping | 2009-09-15 → 2009-09-25 A (+10d) | 2009-09-22 → 2009-09-29 A (+7d) | 8d? → 5d? | 0% → 100% | 87d → none |  |
| 12 | SOW | 2009-09-15 → 2009-09-16 A (+1d) | 2009-09-22 A | 8d? → 7d? | 0% → 100% | 87d → none |  |
| 13 | **Reporting** | 2009-09-25 → 2009-09-24 A (-1d) | 2009-12-18 A |  | 0% → 100% | 0d → none |  |
| 14 | **Final Presentation** | 2009-10-17 → 2009-10-16 A (-1d) | 2009-12-18 → 2009-12-17 A (-1d) |  | 0% → 100% | 0d → none |  |
| 15 | Rough Draft Presentation | 2009-10-17 → 2009-10-16 A (-1d) | 2009-11-13 → 2009-11-12 A (-1d) |  | 0% → 100% | 0d → none |  |
| 16 | Final Draft Presentation | 2009-11-14 → 2009-11-13 A (-1d) | 2009-12-18 → 2009-12-17 A (-1d) |  | 0% → 100% | 0d → none |  |
| 17 | **Final Report** | 2009-10-17 → 2009-10-16 A (-1d) | 2009-12-18 → 2009-12-17 A (-1d) |  | 0% → 100% | 0d → none |  |
| 18 | Rough Draft Report | 2009-10-17 → 2009-10-16 A (-1d) | 2009-11-13 → 2009-11-12 A (-1d) |  | 0% → 100% | 0d → none |  |
| 19 | Final Draft Report | 2009-11-14 → 2009-11-13 A (-1d) | 2009-12-18 → 2009-12-17 A (-1d) |  | 0% → 100% | 0d → none |  |
| 20 | **Reviews** | 2009-09-25 → 2009-09-24 A (-1d) | 2009-12-18 A | 83d → 84d | 0% → 100% | 1d → none |  |
| 21 | SRR | 2009-09-25 → 2009-09-24 A (-1d) | 2009-09-25 → 2009-09-24 A (-1d) |  | 0% → 100% | 84d → none |  |
| 22 | CDR | 2009-12-18 A | 2009-12-18 A |  | 0% → 100% | 1d → none |  |
| 23 | **Systems Engineering Management** | 2009-09-15 → 2009-09-14 A (-1d) | 2009-10-05 → 2009-10-12 (+7d) | 21d? → 29d? | 0% → 91% | 74d → 66d |  |
| 24 | Systems Engineering Tools Selection | 2009-09-15 → 2009-09-14 A (-1d) | 2009-09-15 → 2009-09-14 A (-1d) |  | 0% → 100% | 94d → none |  |
| 25 | CM | 2009-09-15 → 2009-09-14 A (-1d) | 2009-09-15 → 2009-09-14 A (-1d) |  | 0% → 100% | 94d → none |  |
| 26 | Systems Engineering Management Plan (SEMP) | 2009-09-15 → 2009-09-22 A (+7d) | 2009-10-05 → 2009-10-12 (+7d) |  | 0% → 80% | 74d → 66d |  |
| 27 | Risk Management Plan (RMP) | 2009-09-15 → 2009-09-25 A (+10d) | 2009-10-05 → 2009-10-06 A (+1d) | 21d? → 12d? | 0% → 100% | 74d → none |  |
| 28 | Product Assurance Plan (PAP) | 2009-09-15 → 2009-09-25 A (+10d) | 2009-10-05 A | 21d? → 11d? | 0% → 100% | 74d → none |  |
| 29 | **System Design** | 2009-09-15 → 2009-09-13 A (-2d) | 2009-10-16 → 2009-10-15 (-1d) | 32d? → 33d? | 0% → 89% | 5d → 63d |  |
| 30 | **Define System Level Design Problem** | 2009-09-15 → 2009-09-13 A (-2d) | 2009-09-26 → 2009-10-07 (+11d) | 12d? → 25d? | 0% → 99% | 5d → 71d |  |
| 31 | Develop Concept of Operation | 2009-09-15 → 2009-09-13 A (-2d) | 2009-09-16 → 2009-10-07 A (+21d) | 2d → 25d | 0% → 100% | 5d → none |  |
| 32 | **Develop External Systems Diagram** | 2009-09-15 → 2009-09-27 A (+12d) | 2009-09-16 → 2009-10-05 A (+19d) | 2d → 9d | 0% → 100% | 93d → none |  |
| 33 | Identify External Interface Requirements | 2009-09-15 → 2009-09-27 A (+12d) | 2009-09-16 → 2009-10-05 A (+19d) | 2d → 9d | 0% → 100% | 93d → none |  |
| 34 | Develop External Systems Activity Diagram | 2009-09-15 → 2009-09-27 A (+12d) | 2009-09-23 → 2009-10-05 A (+12d) |  | 0% → 100% | 86d → none |  |
| 35 | Develop External Systems Diagram | 2009-09-15 → 2009-09-27 A (+12d) | 2009-09-16 → 2009-10-05 A (+19d) | 2d? → 9d? | 0% → 100% | 5d → none |  |
| 36 | Develop Systems Objectives Hierarchy | 2009-09-15 → 2009-09-14 A (-1d) | 2009-09-16 → 2009-09-15 A (-1d) |  | 0% → 100% | 93d → none |  |
| 37 | **Develop Analyze and Refine Requirements** | 2009-09-17 → 2009-09-16 A (-1d) | 2009-09-25 → 2009-10-05 A (+10d) | 9d → 20d | 0% → 100% | 5d → none |  |
| 38 | Develop Use Cases for CONOPs | 2009-09-17 → 2009-09-16 A (-1d) | 2009-09-17 → 2009-10-05 A (+18d) | 1d → 20d | 0% → 100% | 5d → none |  |
| 39 | Define Draft Requirements | 2009-09-24 → 2009-09-18 A (-6d) | 2009-09-24 → 2009-09-23 A (-1d) | 1d → 6d | 0% → 100% | 0d → none | 38, Develop Sequence Diagrams for Use Cases, Develop Communications Diagram, Systems Objectives Hierarchy, 10 → 38, 10 |
| 40 | Define Qualification Requirements | 2009-09-18 A | 2009-09-18 → 2009-09-23 A (+5d) | 1d → 6d | 0% → 100% | 91d → none |  |
| 41 | Ensure Requirements Feasibility | 2009-09-25 → 2009-09-24 A (-1d) | 2009-09-25 → 2009-09-24 A (-1d) |  | 0% → 100% | 0d → none |  |
| 42 | Obtain Approval for Requirements | 2009-09-25 → 2009-09-24 (-1d) | 2009-09-25 → 2009-09-24 (-1d) |  |  | 0d → 83d |  |
| 43 | Document Final Requirements | 2009-09-26 → 2009-09-25 (-1d) | 2009-09-26 → 2009-09-25 (-1d) |  |  | 0d → 83d |  |
| 44 | **Develop System Functional Architecture** | 2009-09-27 → 2009-09-16 A (-11d) | 2009-10-03 → 2009-10-12 (+9d) | 7d → 26.5d | 0% → 94% | 0d → 66.5d |  |
| 45 | Create Simple Functional Concept | 2009-09-27 → 2009-09-26 A (-1d) | 2009-09-27 → 2009-09-26 A (-1d) |  | 0% → 100% | 0d → none |  |
| 46 | **Draft and Evaluate Functional Model** | 2009-09-28 → 2009-09-16 A (-12d) | 2009-09-30 → 2009-10-10 A (+10d) | 3d → 25d | 0% → 100% | 0d → none |  |
| 47 | Conduct Functional Decomposition Brainstorming | 2009-09-28 → 2009-09-16 A (-12d) | 2009-09-28 → 2009-09-23 A (-5d) | 1d → 8d | 0% → 100% | 0d → none |  |
| 48 | Conduct Functional Decomposition Trade-Study | 2009-09-29 → 2009-09-27 A (-2d) | 2009-09-29 → 2009-10-10 A (+11d) | 1d → 14d | 0% → 100% | 0d → none |  |
| 49 | Select Functional Decomposition | 2009-09-30 → 2009-10-10 A (+10d) | 2009-09-30 → 2009-10-10 A (+10d) |  | 0% → 100% | 0d → none |  |
| 50 | **Complete Functional and Data Models** | 2009-10-01 → 2009-09-30 A (-1d) | 2009-10-01 → 2009-10-11 (+10d) | 1d → 11.25d | 0% → 83% | 0d → 66.5d |  |
| 51 | Generate Initial Functional Model | 2009-10-01 → 2009-09-30 A (-1d) | 2009-10-01 → 2009-09-30 A (-1d) |  | 0% → 100% | 0d → none |  |
| 52 | Generate Activity Diagrams | 2009-10-01 → 2009-09-30 A (-1d) | 2009-10-01 → 2009-10-11 (+10d) |  | 0% → 75% | 0d → 66.5d |  |
| 53 | Identify Draft Sub-System Interface Requirements | 2009-10-01 → 2009-09-30 A (-1d) | 2009-10-01 → 2009-10-11 (+10d) |  | 0% → 75% | 0d → 66.5d |  |
| 54 | **Trace Input / Output Requirements** | 2009-10-02 → 2009-10-01 A (-1d) | 2009-10-02 → 2009-10-11 (+9d) | 1d → 10.5d | 0% → 75% | 0d → 66.5d |  |
| 55 | Complete Draft IDEF A0 Diagram | 2009-10-02 → 2009-10-01 A (-1d) | 2009-10-02 → 2009-10-11 (+9d) |  | 0% → 75% | 0d → 66.5d |  |
| 56 | Obtain Approval for Functional Architecture | 2009-10-02 → 2009-10-11 (+9d) | 2009-10-02 → 2009-10-11 (+9d) |  |  | 0d → 66.5d |  |
| 57 | Document Final Functional Architecture | 2009-10-03 → 2009-10-11 (+8d) | 2009-10-03 → 2009-10-12 (+9d) |  |  | 0d → 66.5d |  |
| 58 | **Develop System Instantiatedl Architecture** | 2009-10-04 → 2009-10-03 A (-1d) | 2009-10-16 → 2009-10-15 (-1d) |  | 0% → 12% | 0d → 3d |  |
| 59 | **Develop Generic Architecture** | 2009-10-04 → 2009-10-03 A (-1d) | 2009-10-06 → 2009-10-05 (-1d) |  | 0% → 50% |  |  |
| 60 | Brainstorm Architecture | 2009-10-04 → 2009-10-03 A (-1d) | 2009-10-04 → 2009-10-03 A (-1d) |  | 0% → 100% | 0d → none |  |
| 61 | Generate Trade-Off Analysis | 2009-10-05 → 2009-10-04 A (-1d) | 2009-10-05 → 2009-10-04 (-1d) |  | 0% → 50% |  |  |
| 62 | Down-Select Generic Architecture | 2009-10-06 → 2009-10-05 (-1d) | 2009-10-06 → 2009-10-05 (-1d) |  |  |  |  |
| 63 | **Develop Instantiated Architecture** | 2009-10-07 → 2009-10-06 (-1d) | 2009-10-15 → 2009-10-14 (-1d) |  |  |  |  |
| 64 | Brainstorm Instantiated Architecture Components | 2009-10-07 → 2009-10-06 (-1d) | 2009-10-07 → 2009-10-06 (-1d) |  |  |  |  |
| 65 | Generate Morphological Box - Instantiated Arch Sub-Sys | 2009-10-08 → 2009-10-07 (-1d) | 2009-10-09 → 2009-10-08 (-1d) |  |  |  |  |
| 66 | Conduct Sub-System Trade-Off Analysis | 2009-10-10 → 2009-10-09 (-1d) | 2009-10-12 → 2009-10-11 (-1d) |  |  |  |  |
| 67 | Down Select Instantiated Architecture | 2009-10-13 → 2009-10-12 (-1d) | 2009-10-13 → 2009-10-12 (-1d) |  |  |  |  |
| 68 | Finalize Sub-System Interface Requirements | 2009-10-14 → 2009-10-13 (-1d) | 2009-10-14 → 2009-10-13 (-1d) |  |  |  |  |
| 69 | Document Instantiated Draft Design | 2009-10-15 → 2009-10-14 (-1d) | 2009-10-15 → 2009-10-14 (-1d) |  |  |  |  |
| 70 | Obtain Approval for Instantiated Design | 2009-10-15 → 2009-10-14 A (-1d) | 2009-10-15 → 2009-10-14 (-1d) |  | 0% → 25% | 0d → 3d |  |

| ID | Task | Start | Finish | Total float |
| --- | --- | --- | --- | --- |
| 71 | Final Instantiated Design | 2009-10-16 → 2009-10-15 (-1d) | 2009-10-16 → 2009-10-15 (-1d) | 0d → 3d |
| 72 | **Refine / Update Design** | 2009-10-17 → 2009-10-16 (-1d) | 2009-12-15 → 2009-12-14 (-1d) |  |
| 73 | System Requirements | 2009-10-17 → 2009-10-16 (-1d) | 2009-12-15 → 2009-12-14 (-1d) |  |
| 74 | Functional Design | 2009-10-17 → 2009-10-16 (-1d) | 2009-12-15 → 2009-12-14 (-1d) |  |
| 75 | Instantiated Design | 2009-10-17 → 2009-10-16 (-1d) | 2009-12-15 → 2009-12-14 (-1d) |  |
